# Sharp schedule(actual)

Schedule from MS Project, 2008-12-01 to 2009-05-22, A marks actual dates.

## Calendars

- Standard: Mon-Fri 08:00-12:00, 13:00-17:00; Sat-Sun off.

## Schedule

| ID | WBS | Task | Type | Duration | Start | Finish | Predecessors | Complete | Remaining | Baseline start | Baseline finish | Baseline duration | Total slack | Free slack | Constraint | Deadline |
| --- | --- | --- | --- | --- | --- | --- | --- | --- | --- | --- | --- | --- | --- | --- | --- | --- |
| 1 | 1 | **ACM SIGSOFT Project** |  | 125d? | 2008-12-01 A | 2009-05-22 |  | 95% | 5.81d? |  |  |  | 0d |  |  |  |
| 2 | 1.1 | **Phase 1** |  | 49d | 2008-12-01 A | 2009-02-05 A |  | 100% |  | 2008-12-01 | 2009-02-05 | 49d |  |  |  |  |
| 3 | 1.1.1 | Establish team processes |  | 1w | 2008-12-01 A | 2008-12-05 A |  | 100% |  | 2008-12-01 | 2008-12-05 | 1w |  |  |  |  |
| 4 | 1.1.2 | Previous project analysis |  | 2w | 2008-12-08 A | 2008-12-19 A | 3 | 100% |  | 2008-12-08 | 2008-12-19 | 2w |  |  |  |  |
| 5 | 1.1.3 | Requirements |  | 4w | 2008-12-14 A | 2009-01-16 A | 3, 4 | 100% |  | 2008-12-14 | 2009-01-16 | 4w |  |  |  |  |
| 6 | 1.1.4 | Architecture |  | 2w | 2009-01-09 A | 2009-01-22 A | 5FF | 100% |  | 2009-01-09 | 2009-01-22 | 2w |  |  |  |  |
| 7 | 1.1.5 | Implementation |  | 5w | 2008-12-12 A | 2009-02-02 A | 5, 6FF | 100% |  | 2008-12-12 | 2009-02-02 | 5w |  |  |  |  |
| 8 | 1.1.6 | Testing |  | 2w | 2009-01-21 A | 2009-02-03 A | 7FF | 100% |  | 2009-01-21 | 2009-02-03 | 2w |  |  |  |  |
| 9 | 1.1.7 | User Documentation |  | 3d | 2009-01-31 A | 2009-02-04 A | 8 | 100% |  | 2009-01-31 | 2009-02-04 | 3d |  |  |  |  |
| 10 | 1.1.8 | Polish release |  | 8d | 2009-01-27 A | 2009-02-05 A | 9, 5, 6, 7, 8 | 100% |  | 2009-01-27 | 2009-02-05 | 8d |  |  |  |  |
| 11 | 1.1.9 | Milestone: Phase 1 Complete | milestone | 0d | 2009-02-05 A | 2009-02-05 A | 10 | 100% |  |  |  |  |  |  |  |  |
| 12 | 1.2 | **Phase 2** |  | 66d | 2009-01-15 A | 2009-04-16 A |  | 100% |  | 2009-01-15 | 2009-04-10 | 62d |  |  |  |  |
| 13 | 1.2.1 | Requirements |  | 1w | 2009-01-15 A | 2009-01-21 A | 5 | 100% |  | 2009-01-15 | 2009-01-28 | 2w |  |  |  |  |
| 14 | 1.2.2 | Architecture |  | 1w | 2009-01-16 A | 2009-01-22 A | 6 | 100% |  | 2009-01-16 | 2009-01-29 | 2w |  |  |  |  |
| 15 | 1.2.3 | Implementation |  | 5w | 2009-03-09 A | 2009-04-10 A | 7 | 100% |  | 2009-02-19 | 2009-03-25 | 4w |  |  | finish no earlier than 2009-04-10 |  |
| 16 | 1.2.4 | Testing |  | 1w | 2009-04-01 A | 2009-04-07 A | 8 | 100% |  | 2009-03-23 | 2009-04-03 | 2w |  |  | start no earlier than 2009-04-01 |  |
| 17 | 1.2.5 | User Documentation |  | 1w | 2009-03-12 A | 2009-03-18 A | 9 | 100% |  | 2009-03-17 | 2009-03-23 | 1w |  |  | start no earlier than 2009-03-12 |  |
| 18 | 1.2.6 | Polish release |  | 4d | 2009-04-13 A | 2009-04-16 A | 13, 14, 15, 16 | 100% |  | 2009-04-06 | 2009-04-10 | 5d |  |  | start no earlier than 2009-03-12 |  |
| 19 | 1.2.7 | Milestone: Phase 2 Complete | milestone | 0d | 2009-04-16 A | 2009-04-16 A | 18 | 100% |  |  |  |  |  |  |  |  |
| 20 | 1.3 | **Phase 3** |  | 82d | 2009-01-29 A | 2009-05-22 |  | 92% | 6.56d | 2009-01-29 | 2009-05-08 | 72d | 0d |  |  | 2009-05-15 |
| 21 | 1.3.1 | Requirements |  | 4w | 2009-01-29 A | 2009-02-25 A | 13SS | 100% |  | 2009-01-29 | 2009-02-11 | 2w |  |  |  |  |
| 22 | 1.3.2 | Architecture |  | 1w | 2009-03-18 A | 2009-03-24 A | 14SS | 100% |  | 2009-03-16 | 2009-03-27 | 2w |  |  | start no earlier than 2009-03-18 |  |
| 23 | 1.3.3 | Implementation |  | 7w | 2009-03-30 A | 2009-05-17 | 15SS | 90% | 0.7w | 2009-03-26 | 2009-04-29 | 5w | 0d |  | finish no earlier than 2009-05-17 |  |
| 24 | 1.3.4 | Testing |  | 6w | 2009-04-07 A | 2009-05-18 | 16SS | 85% | 0.9w | 2009-04-10 | 2009-04-30 | 3w | -1d | 0d | start no earlier than 2009-04-10 |  |
| 25 | 1.3.5 | User Documentation |  | 1w | 2009-04-20 A | 2009-04-24 A | 17SS | 100% |  | 2009-04-20 | 2009-05-01 | 2w |  |  | start no earlier than 2009-04-19 |  |
| 26 | 1.3.6 | Polish release |  | 5d | 2009-05-18 A | 2009-05-22 A | 21, 22, 23, 24, 25 | 100% |  | 2009-05-04 | 2009-05-08 | 5d |  |  |  |  |
| 27 | 1.3.7 | Milestone: Phase 3 Complete | milestone | 0d | 2009-05-22 A | 2009-05-22 A | 26 | 100% |  |  |  |  |  |  | finish no earlier than 2009-05-17 |  |
| 28 | 1.4 | Develop Interim Presentation |  | 2d | 2009-02-06 A | 2009-02-09 A | 3, 4, 5, 6, 7, 8, 9, 10 | 100% |  | 2009-02-06 | 2009-02-09 | 2d |  |  |  |  |
| 29 | 1.5 | Develop Final Presentation |  | 0.6w | 2009-05-07 A | 2009-05-11 A | 12SS, 20SS | 100% |  | 2009-05-11 | 2009-05-15 | 1w |  |  | start no earlier than 2009-05-07 |  |
| 30 | 1.6 | Create Senior Project Poster |  | 1.2w | 2009-04-15 A | 2009-04-22 A | 29 | 100% |  |  |  |  |  |  | finish no earlier than 2009-04-22 |  |
| 31 | 1.7 | Server Setup |  | 2d | 2009-05-14 A | 2009-05-17 A |  | 100% |  |  |  |  |  |  | finish no earlier than 2009-05-17 |  |
| 32 | 1.8 | Update documentation |  | 4d | 2009-05-14 A | 2009-05-19 |  | 25% | 3d |  |  |  | 3d |  | finish no earlier than 2009-05-17 |  |
